# Project Plan Self Assessment

Schedule from MS Project, 2005-01-12 to 2005-10-31, A marks actual dates.
TUT

## Calendars

- Standard: Mon-Fri 08:00-12:00, 13:00-17:00; Sat-Sun off.

## Resources

| Resource |
| --- |
| Ethney |
| Dhaya |
| Johnny |
| Programme Group |
| Faculty Office |
| DQP |
| DQP(Johnny) |
| Panel Members |
| Betsie |

## Schedule

| ID | WBS | Task | Duration | Start | Finish | Complete | Remaining | Total slack | Constraint | Resources | Work | Actual work |
| --- | --- | --- | --- | --- | --- | --- | --- | --- | --- | --- | --- | --- |
| 1 | 1 | **Programme Review** | 209d? | 2005-01-12 A | 2005-10-31 |  | 208.55d? | 0d |  |  | 4712h | 8h |
| 2 | 1.1 | Introduction and Orientation | 60d | 2005-01-12 | 2005-04-05 |  |  | 149d |  | DQP | 480h |  |
| 3 | 1.2 | Consultation and Support | 156d | 2005-01-12 | 2005-08-17 |  |  | 53d |  | DQP | 1248h |  |
| 4 | 1.3 | **Programme Group Planning and Organization** | 105d | 2005-01-24 | 2005-06-17 |  |  | 96d |  | Programme Group | 1856h |  |
| 5 | 1.3.1 | Establish review committee | 3d | 2005-01-24 | 2005-01-26 |  |  | 198d | start no earlier than 2005-01-24 | Programme Group | 24h |  |
| 6 | 1.3.2 | Analyse programme review instrument | 10d | 2005-01-24 | 2005-02-04 |  |  | 191d | finish no earlier than 2005-02-04 | Programme Group | 80h |  |
| 7 | 1.3.3 | **Develop project plan** | 5d | 2005-02-07 | 2005-02-11 |  |  | 186d |  | Programme Group | 160h |  |
| 8 | 1.3.3.1 | Identify key tasks | 5d | 2005-02-07 | 2005-02-11 |  |  | 186d | finish no earlier than 2005-02-11 | Programme Group | 40h |  |
| 9 | 1.3.3.2 | Allocate roles and responsibilities | 5d | 2005-02-07 | 2005-02-11 |  |  | 186d | finish no earlier than 2005-02-11 | Programme Group | 40h |  |
| 10 | 1.3.3.3 | Identify targets and milestones | 5d | 2005-02-07 | 2005-02-11 |  |  | 186d | finish no earlier than 2005-02-11 | Programme Group | 40h |  |
| 11 | 1.3.4 | **Information management** | 35d | 2005-02-14 | 2005-04-01 |  |  | 151d |  |  | 280h |  |
| 12 | 1.3.4.1 | Data Collection | 10d | 2005-02-14 | 2005-02-25 |  |  | 176d | finish no earlier than 2005-02-25 | Programme Group | 80h |  |
| 13 | 1.3.4.2 | Data Collation | 10d | 2005-02-28 | 2005-03-11 |  |  | 166d | finish no earlier than 2005-03-11 | Programme Group | 80h |  |
| 14 | 1.3.4.3 | Data Verification | 5d | 2005-03-14 | 2005-03-18 |  |  | 161d | finish no earlier than 2005-03-18 | Programme Group | 40h |  |
| 15 | 1.3.4.4 | Supporting Evidence | 10d | 2005-03-21 | 2005-04-01 |  |  | 151d | finish no earlier than 2005-04-01 | Programme Group | 80h |  |
| 16 | 1.3.5 | **Portfolio Development** | 90d | 2005-02-14 | 2005-06-17 |  |  | 96d |  |  | 472h |  |
| 17 | 1.3.5.1 | Allocation of writing tasks | 1d | 2005-02-14 | 2005-02-14 |  |  | 185d | start no earlier than 2005-02-14 | Programme Group | 8h |  |
| 18 | 1.3.5.2 | Writing of various sections | 15d | 2005-04-04 | 2005-04-22 |  |  | 136d | start no earlier than 2005-04-04 | Programme Group | 120h |  |
| 19 | 1.3.5.3 | Consolidation of first draft | 10d | 2005-04-25 | 2005-05-06 |  |  | 126d | start no earlier than 2005-04-25 | Programme Group | 80h |  |
| 20 | 1.3.5.4 | Circulation of first draft for comment | 1d | 2005-05-09 | 2005-05-09 |  |  | 125d | start no earlier than 2005-05-09 | Programme Group | 8h |  |
| 21 | 1.3.5.5 | Comment from programme group | 5d | 2005-05-09 | 2005-05-13 |  |  | 121d | start no earlier than 2005-05-09 | Programme Group | 40h |  |
| 22 | 1.3.5.6 | Development of second draft | 10d | 2005-05-16 | 2005-05-27 |  |  | 111d | start no earlier than 2005-05-16 | Programme Group | 80h |  |
| 23 | 1.3.5.7 | Circulation of second draft for comment | 1d | 2005-05-30 | 2005-05-30 |  |  | 110d | start no earlier than 2005-05-30 | Programme Group | 8h |  |
| 24 | 1.3.5.8 | Comments on second draft | 5d | 2005-05-30 | 2005-06-03 |  |  | 106d | start no earlier than 2005-05-30 | Programme Group | 40h |  |
| 25 | 1.3.5.9 | Compilation of final draft, appendices, and supporting documentation | 10d | 2005-06-06 | 2005-06-17 |  |  | 96d | start no earlier than 2005-06-06 | Programme Group | 80h |  |
| 26 | 1.3.5.10 | Programme group signs of final copy | 1d | 2005-06-17 | 2005-06-17 |  |  | 96d | start no earlier than 2005-06-17 | Programme Group | 8h |  |
| 27 | 1.4 | Programme group submits portfolio to DQP | 1d | 2005-06-20 A | 2005-06-20 A | 100% |  |  | start no earlier than 2005-02-06 | Programme Group | 8h | 8h |
| 28 | 1.5 | Appointment of review panel | 5d | 2005-05-23 | 2005-05-27 |  |  | 111d | start no earlier than 2005-05-23 | DQP | 40h |  |
| 29 | 1.6 | Orienatation of panel members on portfolio review | 5d | 2005-06-06 | 2005-06-10 |  |  | 101d | start no earlier than 2005-06-06 | DQP | 40h |  |
| 30 | 1.7 | Distribution of portfolio to review panel | 5d | 2005-06-20 | 2005-06-24 |  |  | 91d | start no earlier than 2005-06-20 | DQP | 40h |  |
| 31 | 1.8 | Panel members analyse portfolio | 15d | 2005-06-20 | 2005-07-08 |  |  | 81d | start no earlier than 2005-06-20 | Panel Members | 120h |  |
| 32 | 1.9 | Finalise site visit programme | 5d | 2005-06-06 | 2005-06-10 |  |  | 101d | start no earlier than 2005-06-06 | DQP | 40h |  |
| 33 | 1.10 | Orientation of panel members and portfolio meeting | 5d | 2005-06-13 | 2005-06-17 |  |  | 96d | start no earlier than 2005-06-13 | DQP | 40h |  |
| 34 | 1.11 | Site Visits | 15d | 2005-07-04 | 2005-07-22 |  |  | 71d | start no earlier than 2005-07-04 | DQP; Panel Members | 240h |  |
| 35 | 1.12 | Compilation of first draft | 20d | 2005-07-25 | 2005-08-19 |  |  | 51d | start no earlier than 2005-07-25 | DQP | 160h |  |
| 36 | 1.13 | First draft to panel members for comment | 1d | 2005-08-22 | 2005-08-22 |  |  | 50d | start no earlier than 2005-08-22 | DQP | 8h |  |
| 37 | 1.14 | Members comments to DQP | 5d | 2005-08-22 | 2005-08-26 |  |  | 46d | start no earlier than 2005-08-22 | Panel Members | 40h |  |
| 38 | 1.15 | Compilation of second draft | 15d | 2005-08-29 | 2005-09-16 |  |  | 31d | start no earlier than 2005-08-29 | DQP | 120h |  |
| 39 | 1.16 | Second draft to panel members and programme group | 3d | 2005-09-19 | 2005-09-21 |  |  | 28d | start no earlier than 2005-09-19 | DQP | 24h |  |
| 40 | 1.17 | Comments to DQP | 7d | 2005-09-21 | 2005-09-29 |  |  | 22d | start no earlier than 2005-09-21 | Programme Group; Panel Members | 112h |  |
| 41 | 1.18 | Final copy | 10d | 2005-10-03 | 2005-10-14 |  |  | 11d | start no earlier than 2005-10-03 | DQP | 80h |  |
| 42 | 1.19 | Final copy to DVC, DEAN, Programme Group | 1d | 2005-10-17 | 2005-10-17 |  |  | 10d | start no earlier than 2005-10-17 | DQP | 8h |  |
| 43 | 1.20 | Programme Improvement plan to DEAN, DVC, DQP | 1d | 2005-10-31 | 2005-10-31 |  |  | 0d | start no earlier than 2005-10-31 | Programme Group | 8h |  |
